# fase Desarrollo

Schedule from MS Project, 2003-10-02 to 2004-06-01, status date 2003-05-18, scheduled back from the finish, A marks actual dates.

## Calendars

- Estándar: Mon-Fri 08:00-14:00, 15:00-17:00; Sat-Sun off.

## Schedule

| ID | Task | Type | Duration | Start | Finish | Complete | Baseline start | Baseline finish | Baseline duration | Total slack | Free slack | Constraint | Deadline |
| --- | --- | --- | --- | --- | --- | --- | --- | --- | --- | --- | --- | --- | --- |
| 1 | Seguimiento y Control de la Etapa de Desarrollo |  | 172d | 2003-10-02 A | 2004-05-28 A | 100% |  |  |  |  |  | start no later than 2003-10-02 |  |
| 2 | Estudio y Revisión de Manuales |  | 172d | 2003-10-02 A | 2004-05-28 A | 100% | 2003-08-01 | 2004-03-19 | 166d |  |  | finish no later than 2004-03-19 |  |
| 3 | Elaborar Codificación de Políticas |  | 7d | 2003-10-02 A | 2003-10-10 A | 100% | 2003-08-01 | 2003-08-11 | 7d |  |  | as late as possible |  |
| 4 | elaborar Componentes y Librerías |  | 7d | 2003-10-03 A | 2003-10-13 A | 100% | 2003-08-03 | 2003-08-12 | 7d |  |  | as late as possible |  |
| 5 | Entrega de librerías y Componentes | milestone | 1d | 2003-12-01 | 2003-12-01 |  |  |  |  | 0d |  | must start on 2003-12-01 | 2003-12-01 |
| 6 | Desarrollo del Sub-sistema de Administración Gestion Administrativay Financiera |  | 123d | 2003-10-13 A | 2004-03-31 A | 100% | 2003-08-13 | 2003-10-13 | 44d |  |  | as late as possible |  |
| 7 | Desarrollo del Sub-sistema de Registro Académico |  | 44d | 2003-10-13 A | 2003-12-11 A | 100% | 2003-08-13 | 2003-10-13 | 44d |  |  | start no later than 2003-08-13 |  |
| 8 | Desarrollo del Sub-sistema de Servicios Técnicos |  | 44d | 2003-10-13 A | 2003-12-11 A | 100% | 2003-08-13 | 2003-10-13 | 44d |  |  | finish no later than 2003-10-13 |  |
| 9 | Entrega de Sistemas Administrativos | milestone | 1d | 2004-06-01 | 2004-06-01 |  |  |  |  | 0d |  | start no earlier than 2004-06-01 |  |
| 10 | Entrega de Sistemas Educativos | milestone | 1d | 2004-06-01 | 2004-06-01 |  |  |  |  | 173d | 0d | start no later than 2004-06-01 |  |
| 11 | Desarrollo del Sub-sistema de Normas y auditorías |  | 23d | 2003-12-12 A | 2004-01-13 A | 100% |  |  |  |  |  | finish no later than 2003-11-14 |  |
| 12 | Desarrollo del Sub-sistema de Diseño de Contenidos Curriculares |  | 24d | 2004-01-14 A | 2004-02-16 A | 100% |  |  |  |  |  | start no later than 2003-10-14 |  |
| 13 | Desarrollo del Sub-sistema de Formación y Capacitación |  | 47d | 2004-01-14 A | 2004-03-18 A | 100% |  |  |  |  |  | start no later than 2003-10-14 |  |
| 14 | Desarrollo del Sub-sistema de Post Venta |  | 47d | 2004-01-14 A | 2004-03-18 A | 100% |  |  |  |  |  | finish no later than 2003-12-17 |  |
| 15 | Desarrollo del Sub-sistema de Marketing |  | 47d | 2004-01-14 A | 2004-03-18 A | 100% |  |  |  |  |  | start no later than 2003-10-14 |  |
| 16 | Desarrrollo del Sub- Sistema de Asesoría Jurídica |  | 50d | 2004-03-19 A | 2004-05-27 A | 100% |  |  |  |  |  | as late as possible |  |
| 17 | Desarrrollo del Sub- Sistema de Proyectos de Cooperación |  | 50d | 2004-03-19 A | 2004-05-27 A | 100% |  |  |  |  |  | start no later than 2003-12-18 |  |
| 18 | Desarrrollo del Sub- Sistema de Gestión Institucional |  | 50d | 2004-03-19 A | 2004-05-27 A | 100% |  |  |  |  |  | start no later than 2003-12-18 |  |
| 19 | Desarrrollo del Sub- Sistema de Recursos Informáticos |  | 50d | 2004-03-19 A | 2004-05-27 A | 100% |  |  |  |  |  | start no later than 2003-12-18 |  |
| 20 | Entrega de Sistemas Administrativos | milestone | 1d | 2004-05-28 | 2004-05-28 |  |  |  |  | 171d | 0d | start no later than 2004-05-28 |  |
| 21 | Entrega de Sistemas Educativos | milestone | 1d | 2004-05-28 | 2004-05-28 |  |  |  |  | 171d | 0d | start no later than 2004-05-28 |  |
